# ResourcesJuly13-2011

Schedule from MS Project, 2011-07-13 to 2011-09-27.

## Calendars

- Standard: Mon-Fri 08:00-12:00, 13:00-17:00; Sat-Sun off.

## Resources

| Resource |
| --- |
| GM |
| Gene |
| Mike Parker |
| Paul Coenen |
| Machine Shop |
| Roman Marin |
| Tom Marion |
| Jim Scholfield |
| Brent |

## Schedule

| ID | Task | Type | Duration | Start | Finish | Total slack | Constraint | Resources | Work |
| --- | --- | --- | --- | --- | --- | --- | --- | --- | --- |
| 1 | build & test |  | 30.77d? | 2011-07-13 | 2011-08-24 | 24.23d |  | Gene [65%] | 160h |
| 2 | Software develop & test |  | 1d? | 2011-07-13 | 2011-07-13 | 54d |  | Brent | 8h |
| 3 | Mob & deploy |  | 19d? | 2011-08-29 | 2011-09-22 | 3d | finish no earlier than 2011-09-22 | Gene | 152h |
| 4 | demob |  | 2d? | 2011-09-26 | 2011-09-27 | 0d | start no earlier than 2011-09-26 | Gene | 16h |
| 5 | Mech Tech |  | 25d? | 2011-07-13 | 2011-08-16 | 30d |  | Mike Parker [60%] | 120h |
| 6 | Build up new E/M cable |  | 4d? | 2011-07-18 | 2011-07-21 | 48d | start no earlier than 2011-07-18 | Jim Scholfield | 32h |
| 7 | Elec Tech |  | 25d? | 2011-07-13 | 2011-08-16 | 30d |  | Paul Coenen [60%] | 120h |
| 8 | Elec Tech |  | 5d? | 2011-07-27 | 2011-08-02 | 40d | start no earlier than 2011-07-27 | Tom Marion | 40h |
| 9 | Fabrication (contingency) |  | 3d? | 2011-07-27 | 2011-07-29 | 42d | start no earlier than 2011-07-27 | Machine Shop | 24h |
| 10 | MB sea test | milestone | 0d | 2011-08-11 | 2011-08-11 | 34d | start no earlier than 2011-08-11 |  |  |
| 11 | Deploy |  | 2d? | 2011-08-10 | 2011-08-11 | 33d | start no earlier than 2011-08-10 | Roman Marin | 16h |
| 12 | Prep for shipping |  | 2d? | 2011-08-16 | 2011-08-17 | 29d | start no earlier than 2011-08-16 | Roman Marin | 16h |
| 13 | Load on truck for shippin | milestone | 0d | 2011-08-17 | 2011-08-17 | 30d | start no earlier than 2011-08-17 |  |  |
